# 08-01_Application

How a schedule from MS Project changed from version to version. A marks actual dates.

## Version 1 (saved 2021-12-01, file 3-10-08-01_Anwendung.mpp)

| ID | Task | Duration | Start | Finish | Predecessors |
| --- | --- | --- | --- | --- | --- |
| 1 | Start | 0d | 2015-12-28 | 2015-12-28 |  |
| 2 | Materiallieferung | 3d | 2015-12-28 | 2015-12-30 | 1 |
| 3 | Bauteil C | 5d | 2015-12-28 | 2016-01-01 | 1 |
| 4 | Bauteil A fräsen | 4d | 2015-12-31 | 2016-01-05 | 2 |
| 5 | Bauteil B hobeln | 7d | 2015-12-31 | 2016-01-08 | 2 |
| 6 | Bauteil C drehen | 4d | 2016-01-04 | 2016-01-07 | 3 |
| 7 | Bauteil D bohren | 5d | 2016-01-04 | 2016-01-08 | 3 |
| 8 | Bauteil A bohren | 5d | 2016-01-06 | 2016-01-12 | 4 |
| 9 | Gruppe montieren | 6d | 2016-01-11 | 2016-01-18 | 5, 6 |
| 10 | Produkt montieren | 1d | 2016-01-19 | 2016-01-19 | 7, 8, 9 |

## Version 2 (saved 2021-12-01, file 3-10-08-02_Projekte.mpp)

Last finish stays 2016-01-19.

Changed:

| ID | Task | Start | Finish | Complete | Total float |
| --- | --- | --- | --- | --- | --- |
| 2 | Materiallieferung | 2015-12-28 A | 2015-12-30 → 2016-01-01 (+2d) | 0% → 46% | none → 0d |
| 3 | Bauteil C | 2015-12-28 A |  | 0% → 50% | none → 2.5d |
| 4 | Bauteil A fräsen | 2015-12-31 A | 2016-01-05 → 2016-01-06 (+1d) | 0% → 25% | none → 0.87d |
| 5 | Bauteil B hobeln | 2015-12-31 A |  | 0% → 50% | none → 4.5d |
| 6 | Bauteil C drehen | 2016-01-04 A |  | 0% → 75% | none → 5.5d |
| 7 | Bauteil D bohren | 2016-01-04 A |  | 0% → 50% | none → 6d |
| 8 | Bauteil A bohren | 2016-01-06 A |  | 0% → 25% | none → 4d |
| 9 | Gruppe montieren | 2016-01-11 A |  | 0% → 75% | none → 0d |

## Version 3 (saved 2021-12-02, file 3-10-08-09_Terminplanung.mpp)

Last finish 2016-01-19 → 2016-02-29 (+41d).

Added:

| ID | Task | Duration | Start | Finish | Predecessors | Constraint |
| --- | --- | --- | --- | --- | --- | --- |
| 7 | Bauteil D | 0d | 2016-01-14 | 2016-01-14 | 3 | start no earlier than 2016-01-11 |

Changed:

| ID | Task | Start | Finish | Duration | Complete | Total float | Predecessors | Other |
| --- | --- | --- | --- | --- | --- | --- | --- | --- |
| 1 | Start | 2015-12-28 → 2016-01-06 (+9d) | 2015-12-28 → 2016-01-06 (+9d) |  |  | 2.5d → 2d |  | constraint none → start no earlier than 2016-01-06; baseline start none → 2016-01-06; baseline finish none → 2016-01-06 |
| 2 | Materiallieferung | 2015-12-28 A → 2016-01-06 (+9d) | 2016-01-01 → 2016-01-15 (+14d) | 3d → 4d | 46% → 0% | 0d → 3d |  | resources none → Projektleiter [2%]; Einkäufer [60%]; Büromaterial [0.1%]; baseline start none → 2016-01-06; baseline finish none → 2016-01-15 |
| 3 | Bauteil C | 2015-12-28 A → 2016-01-08 (+11d) | 2016-01-01 → 2016-01-14 (+13d) |  | 50% → 0% | 2.5d → 0d |  | constraint none → start no earlier than 2016-01-08; resources none → Einkäufer [60%]; Projektleiter [2%]; Büromaterial [0.1%]; baseline start none → 2016-01-06; baseline finish none → 2016-01-12 |
| 4 | Bauteil A fräsen | 2015-12-31 A → 2016-01-18 (+18d) | 2016-01-06 → 2016-02-01 (+26d) | 4d → 8d | 25% → 0% | 0.87d → 14d |  | resources none → Projektleiter [5%]; Mechaniker [80%]; Fräsmaschine; Büromaterial [0.1%]; baseline start none → 2016-01-18; baseline finish none → 2016-02-01 |
| 5 | Bauteil B hobeln | 2015-12-31 A → 2016-01-18 (+18d) | 2016-01-08 → 2016-02-15 (+38d) | 7d → 11d | 50% → 0% | 4.5d → 3d |  | resources none → Projektleiter [5%]; Mechaniker [80%]; Hobelbank; Büromaterial [0.1%]; baseline start none → 2016-01-18; baseline finish none → 2016-02-10 |
| 6 | Bauteil C drehen | 2016-01-04 A → 2016-01-15 (+11d) | 2016-01-07 → 2016-02-18 (+42d) | 4d → 8d | 75% → 0% | 5.5d → 0d |  | resources none → Projektleiter [5%]; Mechaniker [80%]; Drehbank; Büromaterial [0.1%]; baseline start none → 2016-01-13; baseline finish none → 2016-02-16 |
| 8 | Bauteil D bohren | 2016-01-04 A → 2016-01-15 (+11d) | 2016-01-08 → 2016-01-21 (+13d) |  | 50% → 0% | 6d → 1d | 3 → 7 | constraint none → finish no later than 2016-01-23; resources none → Projektleiter [5%]; Bohrmaschine; Büromaterial [0.1%]; baseline start none → 2016-01-13; baseline finish none → 2016-01-19 |
| 9 | Bauteil A bohren | 2016-01-06 A → 2016-02-02 (+27d) | 2016-01-12 → 2016-02-08 (+27d) |  | 25% → 0% | 4d → 14d |  | resources none → Projektleiter [5%]; Mechaniker [80%]; Bohrmaschine; Büromaterial [0.1%]; baseline start none → 2016-02-02; baseline finish none → 2016-02-08 |
| 10 | Gruppe montieren | 2016-01-11 A → 2016-02-19 (+39d) | 2016-01-18 → 2016-02-26 (+39d) |  | 75% → 0% |  |  | resources none → Projektleiter [1%]; Monteur; Kühlmittel; Büromaterial [0.1%]; baseline start none → 2016-02-17; baseline finish none → 2016-02-24 |
| 11 | Produkt montieren | 2016-01-19 → 2016-02-29 (+41d) | 2016-01-19 → 2016-02-29 (+41d) |  |  |  |  | resources none → Projektleiter [1%]; Monteur; Kühlmittel; Büromaterial [0.1%]; baseline start none → 2016-02-25; baseline finish none → 2016-02-25 |

## Version 4 (saved 2021-12-02, file 3-10-08-08_Ansichten.mpp)

Last finish 2016-02-29 → 2016-02-25 (-4d).

Removed: 7 Bauteil D

Changed:

| ID | Task | Start | Finish | Duration | Total float | Predecessors | Other |
| --- | --- | --- | --- | --- | --- | --- | --- |
| 2 | Materiallieferung |  |  | 4d → 6d | 3d → 4d |  |  |
| 3 | Bauteil C | 2016-01-08 → 2016-01-06 (-2d) | 2016-01-14 → 2016-01-12 (-2d) |  |  |  | constraint start no earlier than 2016-01-08 → none |
| 5 | Bauteil B hobeln |  | 2016-02-15 → 2016-02-10 (-5d) | 11d → 9d | 3d → 4d |  |  |
| 6 | Bauteil C drehen | 2016-01-15 → 2016-01-13 (-2d) | 2016-02-18 → 2016-02-16 (-2d) |  |  |  |  |
| 7 | Bauteil D bohren | 2016-01-15 → 2016-01-13 (-2d) | 2016-01-21 → 2016-01-19 (-2d) |  | 1d → 26d | Bauteil D → 3 | constraint finish no later than 2016-01-23 → none; resources Projektleiter [5%]; Bohrmaschine; Büromaterial [0.1%] → Projektleiter [5%]; Mechaniker [80%]; Bohrmaschine; Büromaterial [0.1%] |
| 9 | Gruppe montieren | 2016-02-19 → 2016-02-17 (-2d) | 2016-02-26 → 2016-02-24 (-2d) |  |  |  |  |
| 10 | Produkt montieren | 2016-02-29 → 2016-02-25 (-4d) | 2016-02-29 → 2016-02-25 (-4d) |  |  |  |  |

## Version 5 (saved 2021-12-02, file 3-10-08-11_Interaktion.mpp)

Last finish 2016-02-25 → 2016-02-29 (+4d). Complete tasks 0 → 3.

Changed:

| ID | Task | Start | Finish | Complete | Total float | Other |
| --- | --- | --- | --- | --- | --- | --- |
| 1 | Start | 2016-01-06 → 2016-01-08 (+2d) | 2016-01-06 → 2016-01-08 (+2d) |  | 0d → 37d | constraint start no earlier than 2016-01-06 → start no earlier than 2016-01-08; baseline start 2016-01-06 → none; baseline finish 2016-01-06 → none |
| 2 | Materiallieferung | 2016-01-06 → 2016-01-08 A (+2d) | 2016-01-15 → 2016-01-19 A (+4d) | 0% → 100% | 4d → none | resources Projektleiter [2%]; Einkäufer [60%]; Büromaterial [0.1%] → Einkäufer [60%]; Projektleiter [2%]; Büromaterial [0.1%]; baseline start 2016-01-06 → none; baseline finish 2016-01-15 → none |
| 3 | Bauteil C | 2016-01-06 → 2016-01-08 A (+2d) | 2016-01-12 → 2016-01-14 A (+2d) | 0% → 100% | 0d → none | baseline start 2016-01-06 → none; baseline finish 2016-01-12 → none |
| 4 | Bauteil A fräsen | 2016-01-18 → 2016-01-20 A (+2d) | 2016-02-01 → 2016-02-03 (+2d) | 0% → 75% | 12d → 1d | resources Projektleiter [5%]; Mechaniker [80%]; Fräsmaschine; Büromaterial [0.1%] → Mechaniker [80%]; Fräsmaschine; Kühlmittel; Projektleiter [5%]; Büromaterial [0.1%]; baseline start 2016-01-18 → none; baseline finish 2016-02-01 → none |
| 5 | Bauteil B hobeln | 2016-01-18 → 2016-01-20 A (+2d) | 2016-02-10 → 2016-02-12 (+2d) | 0% → 60% |  | resources Projektleiter [5%]; Mechaniker [80%]; Hobelbank; Büromaterial [0.1%] → Mechaniker [80%]; Hobelbank; Kühlmittel; Projektleiter [5%]; Büromaterial [0.1%]; baseline start 2016-01-18 → none; baseline finish 2016-02-10 → none |
| 6 | Bauteil C drehen | 2016-01-13 → 2016-01-15 A (+2d) | 2016-02-16 → 2016-02-18 A (+2d) | 0% → 100% | 0d → none | resources Projektleiter [5%]; Mechaniker [80%]; Drehbank; Büromaterial [0.1%] → Mechaniker [80%]; Drehbank; Kühlmittel; Projektleiter [5%]; Büromaterial [0.1%]; baseline start 2016-01-13 → none; baseline finish 2016-02-16 → none |
| 7 | Bauteil D bohren | 2016-01-13 → 2016-01-15 A (+2d) | 2016-01-19 → 2016-01-21 (+2d) | 0% → 65% |  | resources Projektleiter [5%]; Mechaniker [80%]; Bohrmaschine; Büromaterial [0.1%] → Mechaniker [80%]; Bohrmaschine; Kühlmittel; Projektleiter [5%]; Büromaterial [0.1%]; baseline start 2016-01-13 → none; baseline finish 2016-01-19 → none |
| 8 | Bauteil A bohren | 2016-02-02 → 2016-02-04 A (+2d) | 2016-02-08 → 2016-02-10 (+2d) | 0% → 20% |  | resources Projektleiter [5%]; Mechaniker [80%]; Bohrmaschine; Büromaterial [0.1%] → Mechaniker [80%]; Bohrmaschine; Kühlmittel; Projektleiter [5%]; Büromaterial [0.1%]; baseline start 2016-02-02 → none; baseline finish 2016-02-08 → none |
| 9 | Gruppe montieren | 2016-02-17 → 2016-02-19 (+2d) | 2016-02-24 → 2016-02-26 (+2d) |  |  | resources Projektleiter [1%]; Monteur; Kühlmittel; Büromaterial [0.1%] → Monteur; Schmiermittel; Projektleiter [1%]; Büromaterial [0.1%]; baseline start 2016-02-17 → none; baseline finish 2016-02-24 → none |
| 10 | Produkt montieren | 2016-02-25 → 2016-02-29 (+4d) | 2016-02-25 → 2016-02-29 (+4d) |  |  | resources Projektleiter [1%]; Monteur; Kühlmittel; Büromaterial [0.1%] → Monteur; Schmiermittel; Projektleiter [1%]; Büromaterial [0.1%]; baseline start 2016-02-25 → none; baseline finish 2016-02-25 → none |
